# Cedarline Pump Station Retrofit (SYNTHETIC EXAMPLE)

Schedule from Primavera P6, 2025-02-03 to 2025-09-24, data date 2025-03-31, A marks actual dates.
Must finish by 2025-09-24

## Calendars

- SYN-5D8H - Standard 5 Day x 8 Hour: Mon-Fri 08:00-12:00, 13:00-17:00; Sat-Sun off. Exceptions (off unless hours are given): 2025-02-17, 2025-04-18, 2025-05-19, 2025-07-01, 2025-08-04, 2025-09-01.

## Schedule

| ID | WBS | Activity | Type | Duration | Start | Finish | Predecessors | Complete | Remaining | Total float |
| --- | --- | --- | --- | --- | --- | --- | --- | --- | --- | --- |
|  | PRE | **Preconstruction** |  |  | 2025-02-03 | 2025-03-04 |  |  |  |  |
| MS-NTP |  | Notice to Proceed | milestone | 0d | 2025-02-03 A | 2025-02-03 A |  | 100% |  |  |
| PRE-MOB |  | Mobilize Site Offices and Laydown |  | 5d | 2025-02-03 A | 2025-02-10 A | MS-NTP | 100% |  |  |
| PRE-PERMIT |  | Building Permit Issuance |  | 20d | 2025-02-03 A | 2025-03-04 A | MS-NTP | 100% |  |  |
| PRE-SHOP |  | Structural Shop Drawings and Review |  | 15d | 2025-02-03 A | 2025-02-25 A | MS-NTP | 100% |  |  |
|  | CIV | **Civil and Structural** |  |  | 2025-02-10 | 2025-06-11 |  |  |  |  |
| CIV-SOE |  | Shoring and Dewatering Install |  | 8d | 2025-02-10 A | 2025-02-21 A | PRE-MOB | 100% |  |  |
| CIV-EXC |  | Bulk Excavation Wet Well |  | 10d | 2025-03-04 A | 2025-03-18 A | PRE-PERMIT, CIV-SOE SS+3d | 100% |  |  |
| CIV-MUD |  | Mud Slab and Survey Layout |  | 4d | 2025-03-18 A | 2025-03-24 A | CIV-EXC | 100% |  |  |
| CIV-BASE |  | Form Reinforce and Pour Base Slab |  | 20d | 2025-03-24 A | 2025-04-22 | CIV-MUD, PRE-SHOP | 50% | 10d | 0d |
| CIV-WALL |  | Form Reinforce and Pour Wet Well Walls |  | 14d | 2025-04-22 | 2025-05-12 | CIV-BASE |  |  | 0d |
| CIV-CURE |  | Wall Cure and Strip Formwork |  | 7d | 2025-05-12 | 2025-05-22 | CIV-WALL |  |  | 0d |
| CIV-BKF |  | Backfill and Compact Around Structure |  | 6d | 2025-05-22 | 2025-05-30 | MS-CONC |  |  | 4d |
| MS-CONC |  | Concrete Structure Complete | milestone | 0d | 2025-05-22 | 2025-05-22 | CIV-CURE |  |  | 0d |
| CIV-SLAB |  | Grade Slab and Equipment Pads |  | 8d | 2025-05-30 | 2025-06-11 | CIV-BKF |  |  | 2d |
|  | MEC | **Mechanical** |  |  | 2025-02-03 | 2025-07-15 |  |  |  |  |
| MEC-PROC |  | Pump Skid Fabrication and Delivery |  | 40d | 2025-02-03 A | 2025-04-01 | MS-NTP | 50% | 20d | 77d |
| MEC-SET |  | Set Pump Skids and Grout Baseplates |  | 8d | 2025-05-22 | 2025-06-03 | MS-CONC, MEC-PROC |  |  | 24d |
| MEC-PIPE |  | Internal Process Piping Install |  | 18d | 2025-06-03 | 2025-06-27 | MEC-SET |  |  | 27d |
| MEC-VALVE |  | Valve and Actuator Install |  | 6d | 2025-06-27 | 2025-07-08 | MEC-PIPE |  |  | 24d |
| MEC-TEST |  | Hydrostatic Test Process Piping |  | 5d | 2025-07-08 | 2025-07-15 | MEC-VALVE |  |  | 27d |
|  | ELE | **Electrical** |  |  | 2025-02-03 | 2025-08-11 |  |  |  |  |
| ELE-PROC |  | MCC and VFD Fabrication and Delivery |  | 47d | 2025-02-03 A | 2025-04-10 | MS-NTP | 50% | 23.5d | 85d |
| ELE-COND |  | Conduit and Cable Tray Rough-In |  | 14d | 2025-06-13 | 2025-07-04 | CIV-SLAB, BLD-ROOF |  |  | 0d |
| ELE-MCC |  | Set MCC and VFD Line-Up |  | 5d | 2025-07-04 | 2025-07-11 | ELE-PROC, ELE-COND |  |  | 0d |
| ELE-CABLE |  | Power and Control Cable Pull |  | 12d | 2025-07-11 | 2025-07-29 | ELE-MCC |  |  | 0d |
| ELE-TERM |  | Terminate and Point-to-Point Check |  | 8d | 2025-07-29 | 2025-08-11 | ELE-CABLE |  |  | 0d |
| MS-ENERG |  | Permanent Power Energized | milestone | 0d | 2025-08-11 | 2025-08-11 | ELE-TERM |  |  | 0d |

| ID | WBS | Activity | Type | Duration | Start | Finish | Predecessors | Complete | Total float |
| --- | --- | --- | --- | --- | --- | --- | --- | --- | --- |
|  | BLD | **Building Envelope** |  |  | 2025-02-03 | 2025-07-02 |  |  |  |
| BLD-PROC |  | Pre-Engineered Building Delivery |  | 30d | 2025-02-03 A | 2025-03-18 A | MS-NTP | 100% |  |
| BLD-ERECT |  | Erect Pre-Engineered Building Frame |  | 10d | 2025-05-22 | 2025-06-05 | MS-CONC, BLD-PROC |  | 0d |
| BLD-ROOF |  | Roof Deck and Membrane |  | 6d | 2025-06-05 | 2025-06-13 | BLD-ERECT |  | 0d |
| BLD-CLAD |  | Wall Cladding and Flashing |  | 8d | 2025-06-13 | 2025-06-25 | BLD-ROOF |  | 85d |
| BLD-DOOR |  | Overhead Doors and Louvres |  | 4d | 2025-06-25 | 2025-07-02 | BLD-CLAD |  | 84d |
|  | COM | **Commissioning and Closeout** |  |  | 2025-08-11 | 2025-09-24 |  |  |  |
| COM-FLUSH |  | System Flush and Chlorination |  | 5d | 2025-08-11 | 2025-08-18 | MEC-TEST, MS-ENERG |  | 0d |
| COM-LOOP |  | Instrument Loop Checks |  | 8d | 2025-08-18 | 2025-08-28 | COM-FLUSH |  | 0d |
| COM-FUNC |  | Functional Testing All Modes |  | 10d | 2025-08-28 | 2025-09-12 | COM-LOOP |  | 0d |
| COM-PERF |  | Performance and Capacity Demonstration |  | 5d | 2025-09-12 | 2025-09-19 | COM-FUNC |  | 0d |
| COM-DEMOB |  | Demobilize and Turnover Documentation |  | 3d | 2025-09-19 | 2025-09-24 | COM-PERF |  | 0d |
| MS-SC |  | Substantial Completion | milestone | 0d | 2025-09-24 | 2025-09-24 | COM-DEMOB, BLD-DOOR |  | 0d |
