# Cedarline Pump Station Retrofit (SYNTHETIC EXAMPLE)

Schedule from Primavera P6, 2025-02-03 to 2025-10-07, data date 2025-09-30, A marks actual dates.
Must finish by 2025-10-07

## Calendars

- SYN-5D8H - Standard 5 Day x 8 Hour: Mon-Fri 08:00-12:00, 13:00-17:00; Sat-Sun off. Exceptions (off unless hours are given): 2025-02-17, 2025-04-18, 2025-05-19, 2025-07-01, 2025-08-04, 2025-09-01.

## Schedule

| ID | WBS | Activity | Type | Duration | Start | Finish | Predecessors | Complete |
| --- | --- | --- | --- | --- | --- | --- | --- | --- |
|  | PRE | **Preconstruction** |  |  | 2025-02-03 | 2025-03-04 |  |  |
| MS-NTP |  | Notice to Proceed | milestone | 0d | 2025-02-03 A | 2025-02-03 A |  | 100% |
| PRE-MOB |  | Mobilize Site Offices and Laydown |  | 5d | 2025-02-03 A | 2025-02-10 A | MS-NTP | 100% |
| PRE-PERMIT |  | Building Permit Issuance |  | 20d | 2025-02-03 A | 2025-03-04 A | MS-NTP | 100% |
| PRE-SHOP |  | Structural Shop Drawings and Review |  | 15d | 2025-02-03 A | 2025-02-25 A | MS-NTP | 100% |
|  | CIV | **Civil and Structural** |  |  | 2025-02-10 | 2025-06-20 |  |  |
| CIV-SOE |  | Shoring and Dewatering Install |  | 8d | 2025-02-10 A | 2025-02-21 A | PRE-MOB | 100% |
| CIV-EXC |  | Bulk Excavation Wet Well |  | 10d | 2025-03-04 A | 2025-03-18 A | PRE-PERMIT, CIV-SOE SS+3d | 100% |
| CIV-MUD |  | Mud Slab and Survey Layout |  | 4d | 2025-03-18 A | 2025-03-24 A | CIV-EXC | 100% |
| CIV-BASE |  | Form Reinforce and Pour Base Slab |  | 20d | 2025-03-24 A | 2025-04-22 A | CIV-MUD, PRE-SHOP | 100% |
| CIV-WALL |  | Form Reinforce and Pour Wet Well Walls |  | 21d | 2025-04-22 A | 2025-05-22 A | CIV-BASE | 100% |
| CIV-CURE |  | Wall Cure and Strip Formwork |  | 7d | 2025-05-22 A | 2025-06-02 A | CIV-WALL | 100% |
| CIV-BKF |  | Backfill and Compact Around Structure |  | 6d | 2025-06-02 A | 2025-06-10 A | MS-CONC | 100% |
| MS-CONC |  | Concrete Structure Complete | milestone | 0d | 2025-06-02 A | 2025-06-02 A | CIV-CURE | 100% |
| CIV-SLAB |  | Grade Slab and Equipment Pads |  | 8d | 2025-06-10 A | 2025-06-20 A | CIV-BKF | 100% |
|  | MEC | **Mechanical** |  |  | 2025-02-03 | 2025-08-01 |  |  |
| MEC-PROC |  | Pump Skid Fabrication and Delivery |  | 40d | 2025-02-03 A | 2025-04-01 A | MS-NTP | 100% |
| MEC-SET |  | Set Pump Skids and Grout Baseplates |  | 8d | 2025-06-02 A | 2025-06-12 A | MS-CONC, MEC-PROC | 100% |
| MEC-PIPE |  | Internal Process Piping Install |  | 24d | 2025-06-12 A | 2025-07-17 A | MEC-SET | 100% |
| MEC-VALVE |  | Valve and Actuator Install |  | 6d | 2025-07-17 A | 2025-07-25 A | MEC-PIPE | 100% |
| MEC-TEST |  | Hydrostatic Test Process Piping |  | 5d | 2025-07-25 A | 2025-08-01 A | MEC-VALVE | 100% |
|  | ELE | **Electrical** |  |  | 2025-02-03 | 2025-08-28 |  |  |
| ELE-PROC |  | MCC and VFD Fabrication and Delivery |  | 47d | 2025-02-03 A | 2025-04-10 A | MS-NTP | 100% |
| ELE-COND |  | Conduit and Cable Tray Rough-In |  | 20d | 2025-06-24 A | 2025-07-23 A | CIV-SLAB, BLD-ROOF | 100% |
| ELE-MCC |  | Set MCC and VFD Line-Up |  | 5d | 2025-07-23 A | 2025-07-30 A | ELE-PROC, ELE-COND | 100% |
| ELE-CABLE |  | Power and Control Cable Pull |  | 12d | 2025-07-30 A | 2025-08-18 A | ELE-MCC | 100% |
| ELE-TERM |  | Terminate and Point-to-Point Check |  | 8d | 2025-08-18 A | 2025-08-28 A | ELE-CABLE | 100% |
| MS-ENERG |  | Permanent Power Energized | milestone | 0d | 2025-08-28 A | 2025-08-28 A | ELE-TERM | 100% |

| ID | WBS | Activity | Type | Duration | Start | Finish | Predecessors | Complete | Remaining | Total float |
| --- | --- | --- | --- | --- | --- | --- | --- | --- | --- | --- |
|  | BLD | **Building Envelope** |  |  | 2025-02-03 | 2025-07-11 |  |  |  |  |
| BLD-PROC |  | Pre-Engineered Building Delivery |  | 30d | 2025-02-03 A | 2025-03-18 A | MS-NTP | 100% |  |  |
| BLD-ERECT |  | Erect Pre-Engineered Building Frame |  | 10d | 2025-06-02 A | 2025-06-16 A | MS-CONC, BLD-PROC | 100% |  |  |
| BLD-ROOF |  | Roof Deck and Membrane |  | 6d | 2025-06-16 A | 2025-06-24 A | BLD-ERECT | 100% |  |  |
| BLD-CLAD |  | Wall Cladding and Flashing |  | 8d | 2025-06-24 A | 2025-07-07 A | BLD-ROOF | 100% |  |  |
| BLD-DOOR |  | Overhead Doors and Louvres |  | 4d | 2025-07-07 A | 2025-07-11 A | BLD-CLAD | 100% |  |  |
|  | COM | **Commissioning and Closeout** |  |  | 2025-08-28 | 2025-10-07 |  |  |  |  |
| COM-FLUSH |  | System Flush and Chlorination |  | 5d | 2025-08-28 A | 2025-09-05 A | MEC-TEST, MS-ENERG | 100% |  |  |
| COM-LOOP |  | Instrument Loop Checks |  | 8d | 2025-09-05 A | 2025-09-17 A | COM-FLUSH | 100% |  |  |
| COM-FUNC |  | Functional Testing All Modes |  | 6d | 2025-09-17 A | 2025-09-25 A | COM-LOOP | 100% |  |  |
| COM-PERF |  | Performance and Capacity Demonstration |  | 5d | 2025-09-25 A | 2025-10-02 | COM-FUNC | 50% | 2.5d | 0d |
| COM-DEMOB |  | Demobilize and Turnover Documentation |  | 3d | 2025-10-02 | 2025-10-07 | COM-PERF |  |  | 0d |
| MS-SC |  | Substantial Completion | milestone | 0d | 2025-10-07 | 2025-10-07 | COM-DEMOB, BLD-DOOR |  |  | 0d |
